# FPL Programme PhasesSept 10 updated

Schedule from MS Project, 2010-04-13 to 2013-01-31.
I.C.A.O.

## Calendars

- Standard: Mon-Fri 08:00-12:00, 13:00-17:00; Sat-Sun off. Exceptions (off unless hours are given): 2010-10-30 08:00-12:00, 13:00-17:00, 2011-07-31 08:00-12:00, 13:00-17:00, 2011-12-31 to 2012-01-01 08:00-12:00, 13:00-17:00, 2012-03-31 to 2012-04-01 08:00-12:00, 13:00-17:00, 2012-06-30 08:00-12:00, 13:00-17:00.

## Resources

| Resource |
| --- |
| Eastern Europe |

## Schedule

| ID | WBS | Task | Type | Duration | Start | Finish | Predecessors | Total slack | Free slack | Constraint |
| --- | --- | --- | --- | --- | --- | --- | --- | --- | --- | --- |
| 1 | 1 | **Programme Phases** |  | 740d? | 2010-04-13 | 2013-01-31 |  | 0d |  |  |
| 2 | 1.1 | **Negotiation and Approval Phase** |  | 0d | 2010-05-03 | 2010-05-03 |  | 725d |  |  |
| 3 | 1.1.1 | **Acceptance and agreement of the changes to the Flight Plan Form by States** |  | 0d | 2010-05-03 | 2010-05-03 |  | 725d |  |  |
| 4 | 1.1.1.1 | All State differences to be identified in the AIP | milestone | 0h | 2010-05-03 | 2010-05-03 |  | 571d |  | start no earlier than 2010-05-03 |
| 5 | 1.1.1.2 | All Regional differences to be identified in the SUPPs | milestone | 0h | 2010-05-03 | 2010-05-03 |  | 571d |  | start no earlier than 2010-05-03 |
| 6 | 1.1.2 | Approval of the amendment by the ICAO Council | milestone | 0h | 2010-05-03 | 2010-05-03 |  | 571d |  | start no earlier than 2010-05-03 |
| 7 | 1.1.3 | This Phase is complete (01/May/2010) | milestone | 0h | 2010-05-03 | 2010-05-03 |  | 569d |  | finish no earlier than 2010-05-03 |
| 8 | 1.2 | **Impact Assessment and Requirements Phase** |  | 190d | 2010-04-13 | 2010-12-31 |  | 46d |  |  |
| 9 | 1.2.1 | **Awareness of impact of changes** |  | 190d | 2010-04-13 | 2010-12-31 |  | 46d |  |  |
| 10 | 1.2.1.1 | **Initial Regional Task Force meetings** |  | 175d | 2010-05-04 | 2010-12-31 |  | 550d |  |  |
| 11 | 1.2.1.1.1 | All regions have had at least one task force meeting |  | 1400h | 2010-05-04 | 2010-12-31 |  | 550d |  | finish no earlier than 2010-12-31 |
| 12 | 1.2.1.2 | **Initial Regional Seminars and Workshops** |  | 190d | 2010-04-13 | 2010-12-31 |  | 550d |  |  |
| 13 | 1.2.1.2.1 | Most have commenced except AFI which is planned for Feb 2011. |  | 1520h | 2010-04-13 | 2010-12-31 |  | 550d |  | finish no earlier than 2010-12-31 |
| 14 | 1.2.1.3 | ICAO HQ guidelines and amendment identification |  | 320h | 2010-05-03 | 2010-06-25 |  | 145d | 0d | start no earlier than 2010-05-03 |
| 15 | 1.2.1.4 | Regional transition strategies |  | 200h | 2010-06-28 | 2010-07-30 | 14 | 145d | 0d |  |
| 16 | 1.3 | **Solution Production Phase** |  | 373d? | 2010-08-02 | 2011-12-31 |  | 32d |  |  |
| 17 | 1.3.1 | **Produce an Inventory of FDP systems** |  | 66d? | 2010-08-02 | 2010-10-30 |  | 32d |  |  |
| 18 | 1.3.1.1 | **Include all Interfaces** |  | 22d? | 2010-08-02 | 2010-08-31 |  | 32d |  |  |
| 19 | 1.3.1.1.1 | AIDC |  | 176h | 2010-08-02 | 2010-08-31 | 15 | 485d |  | finish no earlier than 2010-08-31 |
| 20 | 1.3.1.1.2 | OLDI |  | 176h | 2010-08-02 | 2010-08-31 | 15 | 485d |  | finish no earlier than 2010-08-31 |
| 21 | 1.3.1.1.3 | CPDLC |  | 176h | 2010-08-02 | 2010-08-31 | 15 | 485d |  | finish no earlier than 2010-08-31 |
| 22 | 1.3.1.1.4 | AMHS |  | 22d? | 2010-08-02 | 2010-08-31 | 15 | 145d | 0d | finish no earlier than 2010-08-31 |
| 23 | 1.3.1.2 | **Include Support systems** |  | 22d | 2010-09-01 | 2010-09-30 |  | 32d |  |  |
| 24 | 1.3.1.2.1 | Record and Replay |  | 176h | 2010-09-01 | 2010-09-30 | 22 | 463d |  | finish no earlier than 2010-09-30 |
| 25 | 1.3.1.2.2 | Conflict Alert Systems |  | 176h | 2010-09-01 | 2010-09-30 | 22 | 145d | 0d | finish no earlier than 2010-09-30 |

Notes:
- 8: This Phase will be complete by the end of 2010.

| ID | WBS | Task | Type | Duration | Start | Finish | Predecessors | Total slack | Free slack | Constraint |
| --- | --- | --- | --- | --- | --- | --- | --- | --- | --- | --- |
| 26 | 1.3.1.3 | **Include discreet management systems** |  | 22d | 2010-10-01 | 2010-10-30 |  | 32d |  |  |
| 27 | 1.3.1.3.1 | Metrics/statistics capture systems |  | 176h | 2010-10-01 | 2010-10-30 | 25 | 441d |  | start no earlier than 2010-09-30 |
| 28 | 1.3.1.3.2 | Route Charges |  | 176h | 2010-10-01 | 2010-10-30 | 25 | 145d | 0d | finish no earlier than 2010-10-30 |
| 29 | 1.3.2 | **Audit the Inventory.** |  | 22d | 2010-11-01 | 2010-11-30 |  | 32d |  |  |
| 30 | 1.3.2.1 | From the Inventory identify those Systems and Interfaces which will require a change. |  | 176h | 2010-11-01 | 2010-11-30 | 28 | 145d | 0d | finish no earlier than 2010-11-30 |
| 31 | 1.3.3 | **Solution Identification** |  | 64d | 2010-12-01 | 2011-02-28 |  | 32d |  |  |
| 32 | 1.3.3.1 | In-house |  | 512h | 2010-12-01 | 2011-02-28 | 30 | 355d |  | finish no earlier than 2011-02-28 |
| 33 | 1.3.3.2 | Vendor provided |  | 512h | 2010-12-01 | 2011-02-28 | 30 | 355d |  | finish no earlier than 2011-02-28 |
| 34 | 1.3.3.3 | Most Vendors will only identify and supply a solution for their own systems |  | 512h | 2010-12-01 | 2011-02-28 | 30 | 355d |  | finish no earlier than 2011-02-28 |
| 35 | 1.3.3.4 | Ensure all systems or interfaces requiring a change are identified |  | 512h | 2010-12-01 | 2011-02-28 | 30 | 145d | 0d | finish no earlier than 2011-02-28 |
| 36 | 1.3.4 | **Solution Production** |  | 210d? | 2011-03-01 | 2011-12-16 |  | 32d |  |  |
| 37 | 1.3.4.1 | In-house |  | 872h | 2011-03-02 | 2011-07-31 | 35 | 314d | 15d | finish no earlier than 2011-07-31 |
| 38 | 1.3.4.2 | In-house testing |  | 85d? | 2011-08-22 | 2011-12-16 | 37 | 299d |  | finish no earlier than 2011-12-16 |
| 39 | 1.3.4.3 | Vendor provided |  | 880h | 2011-03-01 | 2011-07-31 | 35 | 145d | 0d | finish no earlier than 2011-07-31 |
| 40 | 1.3.5 | Factory testing if Vendor supplied |  | 640h | 2011-08-29 | 2011-12-16 | 39 | 12d | 5d | finish no earlier than 2011-12-16 |
| 41 | 1.3.6 | This Phase should complete by 31st Dec 2011 | milestone | 0h | 2011-12-31 | 2011-12-31 |  | 134d |  | finish no earlier than 2011-12-31 |
| 42 | 1.4 | **Transition Phase 1** |  | 60d | 2012-01-09 | 2012-03-30 |  | 222d |  |  |
| 43 | 1.4.1 | **ANSP Implementation** |  | 60d | 2012-01-09 | 2012-03-30 |  | 222d |  |  |
| 44 | 1.4.1.1 | **Solution Delivery and Testing** |  | 60d | 2012-01-09 | 2012-03-30 |  | 222d |  |  |
| 45 | 1.4.1.1.1 | Development system |  | 480h | 2012-01-09 | 2012-03-30 | 41 | 222d |  | finish no earlier than 2012-03-30 |
| 46 | 1.4.1.1.2 | Offline system |  | 480h | 2012-01-09 | 2012-03-30 | 41 | 222d |  | finish no earlier than 2012-03-30 |
| 47 | 1.4.1.1.3 | Training system |  | 480h | 2012-01-09 | 2012-03-30 | 41 | 222d |  | finish no earlier than 2012-03-30 |
| 48 | 1.5 | **Identify Key Transition Entry criteria** |  | 179d? | 2011-07-31 | 2012-03-31 |  | 113d |  |  |
| 49 | 1.5.1 | All safety assurances available |  | 1240h | 2011-08-29 | 2012-03-28 |  | 224d |  | start no earlier than 2011-08-28 |
| 50 | 1.5.2 | All training complete |  | 192h | 2012-02-29 | 2012-03-31 |  | 221d |  | start no earlier than 2012-02-29 |
| 51 | 1.5.3 | All documentation produced and distributed |  | 528h | 2012-01-02 | 2012-03-31 |  | 221d |  | finish no earlier than 2012-03-31 |
| 52 | 1.5.4 | Operational Interfaces checked with adjacent centres using FPL data of NEW, PRESENT and NEW to PRESENT |  | 488h | 2011-12-26 | 2012-03-15 | 40 | 7d | 0d | start no earlier than 2011-12-25 |
| 53 | 1.5.5 | Transition rehearsals complete on Operational Systems |  | 48h | 2012-03-16 | 2012-03-23 | 52 | 7d |  | start no earlier than 2012-03-15 |

Notes:
- 42: Transition Phase 1 1 Jan 2012- 31 March 2012
- 53: All transition prerequesites complete ........now ready to transition into operation

| ID | WBS | Task | Type | Duration | Start | Finish | Predecessors | Total slack | Free slack | Constraint |
| --- | --- | --- | --- | --- | --- | --- | --- | --- | --- | --- |
| 54 | 1.5.6 | **Produce a Transition Plan** |  | 106d? | 2011-07-31 | 2011-12-23 |  | 231d |  |  |
| 55 | 1.5.6.1 | produce a plan |  | 67d? | 2011-07-31 | 2011-10-31 |  | 231d | 0d | finish no earlier than 2011-10-31 |
| 56 | 1.5.6.2 | walk-through the Plan |  | 312h | 2011-11-01 | 2011-12-23 | 55 | 231d | 0d | finish no earlier than 2011-12-23 |
| 57 | 1.5.7 | **Produce and validate a reversion Plan** |  | 50d? | 2011-12-26 | 2012-02-29 |  | 231d |  |  |
| 58 | 1.5.7.1 | produce a reversion plan |  | 30d? | 2011-12-26 | 2012-02-01 | 56 | 231d | 0d | finish no earlier than 2012-01-31 |
| 59 | 1.5.7.2 | walk-through the Plan |  | 160h | 2012-02-02 | 2012-02-29 | 58 | 231d | 10d | finish no earlier than 2012-02-29 |
| 60 | 1.5.8 | **Operational Readiness Demonstration (ORD)** |  | 13d | 2012-03-15 | 2012-03-31 |  | 221d |  |  |
| 61 | 1.5.8.1 | to Users |  | 104h | 2012-03-15 | 2012-03-31 | 59 | 221d |  | start no earlier than 2012-03-15 |
| 62 | 1.5.8.2 | to Management |  | 104h | 2012-03-15 | 2012-03-31 | 59 | 221d |  | start no earlier than 2012-03-15 |
| 63 | 1.5.8.3 | to Regulators |  | 104h | 2012-03-15 | 2012-03-31 | 59 | 221d |  | start no earlier than 2012-03-15 |
| 64 | 1.5.8.4 | to any other Key Stakeholders |  | 104h | 2012-03-15 | 2012-03-31 | 59 | 221d |  | start no earlier than 2012-03-15 |
| 65 | 1.5.9 | Transition Phase 1 complete | milestone | 528h | 2012-01-02 | 2012-03-31 |  | 221d |  | finish no earlier than 2012-03-31 |
| 66 | 1.6 | **Transition Phase 2** |  | 67d? | 2012-04-02 | 2012-07-02 |  | 0d |  |  |
| 67 | 1.6.1 | Transition into Operations |  | 528h | 2012-04-02 | 2012-06-30 | 53 | 0d |  | finish no earlier than 2012-06-30 |
| 68 | 1.6.2 | transition Phase 2 complete | milestone | 1d? | 2012-07-02 | 2012-07-02 | 67 | 0d |  | start no earlier than 2012-06-30 |
| 69 | 1.7 | **Transition phase 3** |  | 98d | 2012-07-03 | 2012-11-15 |  | 0d |  |  |
| 70 | 1.7.1 | Airspace User Implementation |  | 784h | 2012-07-03 | 2012-11-15 | 68 | 0d |  | start no earlier than 2012-07-02 |
| 71 | 1.7.2 | transition Phase 3 complete | milestone | 0h | 2012-11-15 | 2012-11-15 | 70 | 0d |  | start no earlier than 2012-11-15 |
| 72 | 1.8 | **Closure phase** |  | 55d | 2012-11-16 | 2013-01-31 |  | 0d |  |  |
| 73 | 1.8.1 | Only NEW Flight Plans filed |  | 440h | 2012-11-16 | 2013-01-31 | 71 | 0d |  | start no earlier than 2012-11-15 |
| 74 | 1.8.2 | End of closure Phase | milestone | 0h | 2013-01-31 | 2013-01-31 | 73 | 0d |  | start no earlier than 2013-01-31 |
| 75 | 2 | **Planned Regional Task Force meetings** |  | 505d? | 2010-10-18 | 2012-09-12 |  | 101d |  |  |
| 76 | 2.1 | NACC |  | 1d? | 2011-03-07 | 2011-03-07 |  | 504d |  | start no earlier than 2011-03-07 |
| 77 | 2.2 | SAM |  | 5d? | 2010-10-18 | 2010-10-22 |  | 601d |  | finish no earlier than 2010-10-22 |
| 78 | 2.3 | WACAF |  | 1d | 2011-02-18 | 2011-02-18 |  | 515d |  | finish no earlier than 2011-02-18 |

Notes:
- 66: Transition Phase 2 1 April 2012 - 30 June 2012
- 67: ALL ANSPs transition sytems to accept NEW Flight Plan Form
- 69: 1Transition Phase 3 1 July 2012 - 15-November 2012
- 70: Airspace User testing and Implementation
- 76: Probably sometime in March yet to be decided where
- 77: Task Force meetings are covered by the SAM/IG meetings
- 78: Joint AFI meeting, probably Nairobi

| ID | WBS | Task | Type | Duration | Start | Finish | Total slack | Constraint | Resources | Work |
| --- | --- | --- | --- | --- | --- | --- | --- | --- | --- | --- |
| 79 | 2.4 | **EURNAT** |  | 166d | 2011-01-24 | 2011-09-09 | 369d |  |  |  |
| 80 | 2.4.1 | Early seminar/workshop |  | 5d | 2011-01-24 | 2011-01-28 | 530d | start no earlier than 2011-01-24 |  |  |
| 81 | 2.4.2 | Later seminar/workshop |  | 5d | 2011-09-05 | 2011-09-09 | 369d | start no earlier than 2011-09-05 |  |  |
| 82 | 2.5 | **MID** |  | 417d? | 2011-02-16 | 2012-09-12 | 101d |  |  |  |
| 83 | 2.5.1 | First quarter of 2011 (Date and venue yet to be confirmed) |  | 1d? | 2011-02-16 | 2011-02-16 | 517d | start no earlier than 2011-02-16 |  |  |
| 84 | 2.5.2 | Third quarter of 2011 (Date and venue yet to be confirmed) |  | 1d? | 2011-09-14 | 2011-09-14 | 366d | start no earlier than 2011-09-14 |  |  |
| 85 | 2.5.3 | First quarter of 2012 (Date and venue yet to be confirmed) |  | 1d? | 2012-03-14 | 2012-03-14 | 234d | start no earlier than 2012-03-14 |  |  |
| 86 | 2.5.4 | Third quarter of 2012 (Date and venue yet to be confirmed) |  | 1d? | 2012-09-12 | 2012-09-12 | 101d | start no earlier than 2012-09-12 |  |  |
| 87 | 2.6 | ESAF |  | 1d | 2011-02-18 | 2011-02-18 | 515d | finish no earlier than 2011-02-18 |  |  |
| 88 | 2.7 | **APAC** |  | 122d | 2011-03-21 | 2011-09-05 | 373d |  |  |  |
| 89 | 2.7.1 | Early 2011 seminar/workshop |  | 1d | 2011-03-21 | 2011-03-21 | 494d | start no earlier than 2011-03-21 |  |  |
| 90 | 2.7.2 | Late 2011 seminar/workshop planned |  | 1d | 2011-09-05 | 2011-09-05 | 373d | start no earlier than 2011-09-05 |  |  |
| 91 | 3 | **Planned Regional Seminars and Workshops** |  | 262d? | 2010-09-13 | 2011-09-09 | 369d |  |  | 40h |
| 92 | 3.1 | NACC |  | 3d? | 2011-03-08 | 2011-03-10 | 501d | finish no earlier than 2011-03-10 |  |  |
| 93 | 3.2 | SAM |  | 4d | 2011-06-27 | 2011-06-30 | 421d | start no earlier than 2011-06-27 |  |  |
| 94 | 3.3 | WACAF |  | 4d? | 2011-02-14 | 2011-02-17 | 516d | finish no earlier than 2011-02-17 |  |  |
| 95 | 3.4 | **EURNAT** |  | 143d? | 2011-01-25 | 2011-08-10 | 391d |  | Eastern Europe | 40h |
| 96 | 3.4.1 | possibly January in Western Europe |  | 1d? | 2011-01-25 | 2011-01-25 | 533d | start no earlier than 2011-01-25 |  |  |
| 97 | 3.4.2 | Eastern Europe |  | 1d? | 2011-08-10 | 2011-08-10 | 391d | start no earlier than 2011-08-09 |  |  |
| 98 | 3.5 | MID |  | 1d? | 2010-09-13 | 2010-09-13 | 630d |  |  |  |
| 99 | 3.6 | ESAF |  | 4d? | 2011-02-14 | 2011-02-17 | 516d | finish no earlier than 2011-02-17 |  |  |
| 100 | 3.7 | **APAC** |  | 126d? | 2011-03-21 | 2011-09-09 | 369d |  |  |  |
| 101 | 3.7.1 | Early 2011 |  | 5d? | 2011-03-21 | 2011-03-25 | 490d | start no earlier than 2011-03-21 |  |  |
| 102 | 3.7.2 | Late 2011 seminar/workshop planned |  | 5d | 2011-09-05 | 2011-09-09 | 369d | start no earlier than 2011-09-05 |  |  |
| 103 | 4 | A Global Forum to be organised in 2011 | milestone | 1d? | 2011-06-01 | 2011-06-01 | 442d | start no earlier than 2011-06-01 |  |  |

Notes:
- 79: 2 planned for 2011
- 80: Possibly January maybe Western Europe
- 81: Likely to be in Eastern Europe
- 82: 4 planned for 2011-2012
- 83: Likely to be Cairo unless a State wishes to provide a venue
- 87: Joint AFI meeting, probably Nairobi
- 88: 2 planned for 2011
- 89: Likely to be in China
- 90: yet to be determined where and when
- 92: Probably sometime in March yet to be decided where
- 93: location and exact date yet to be agreed
- 94: Joint AFI meeting, probably Nairobi
- 95: 2 planned in 2011
- 98: To be planned
- 99: Joint AFI meeting, probably Nairobi
- 100: 2 planned for 2011
- 101: Likely to be in China
- 102: yet to be determined where and when
- 103: Location and date yet to be decided
